# PROGRAMACION CONSORCIO VIAL CALI 2024 LOTE 1

Schedule from MS Project, 2025-02-03 to 2025-05-17, status date 2024-09-04, costs in $.

## Calendars

- LOTE2: Mon-Sat 08:00-12:00, 13:00-17:00; Sun off.

## Schedule

| ID | WBS | Task | Duration | Start | Finish | Predecessors | Total slack | Constraint | Cost | INICIO | FINAL |
| --- | --- | --- | --- | --- | --- | --- | --- | --- | --- | --- | --- |
| 1 | 1 | **FRENTE 2 LOTE 2** | 90d | 2025-02-03 | 2025-05-17 |  | 0d |  | 613,254,504.27 |  |  |
| 2 | 1.1 | **CONSORCIO VIAL CALI LOTE 2 -FRENTE NUMERO 27 - LA LEONERA - VEREDA CABECERA PARTE ALTA VIA VEREDA EL PORVENIR** | 61d | 2025-02-03 | 2025-04-14 |  | 0d |  | 53,928,379.18 |  |  |
| 3 | 1.1.1 | **RELLENOS Y BASES** | 10d | 2025-02-03 | 2025-02-13 |  | 0d |  | 770,928 |  |  |
| 4 | 1.1.1.1 | SUMINISTRO E INSTALACIÓN DE MATERIAL SELECCIONADO TIPO ROCAMUERTA PARA VÍAS. | 10d | 2025-02-03 | 2025-02-13 |  | 0d | start no earlier than 2025-02-03 | 770,928 | Día1 | Día10 |
| 5 | 1.1.2 | **CONCRETOS** | 33d | 2025-02-17 | 2025-03-26 |  | 0d |  | 37,778,985.53 |  |  |
| 6 | 1.1.2.1 | CONSTRUCCIÓN DE HUELLAS EN CONCRETO SIMPLE MR-38. INCLUYE ANTISOL Y JUNTA. | 20d | 2025-02-17 | 2025-03-11 | 4FS+2d | 0d |  | 33,863,306 | Día13 | Día32 |
| 7 | 1.1.2.2 | EMPEDRADO PLACA HUELLA- CONCRETO 3000 PSI 60% Y PIEDRA 40%-E=15CMS, INCLUYE CURADO CON ANTISOL. | 12d | 2025-03-13 | 2025-03-26 | 6FS+1d | 0d |  | 1,962,038.17 | Día34 | Día45 |
| 8 | 1.1.2.3 | CONSTRUCCIÓN DE VIGUETA DE AMARRE EN CONCRETO DE F'C=3500 PSI DE 15X15 CMS. INCLUYE SUMINISTRO DE CONCRETO SIMPLE, FORMALETA Y CURADO CON ANTISOL. | 6d | 2025-03-20 | 2025-03-26 | 7FF | 45d |  | 1,953,641.36 | Día40 | Día45 |
| 9 | 1.1.3 | **ACEROS** | 14d | 2025-02-24 | 2025-03-11 |  | 58d |  | 747,878 |  |  |
| 10 | 1.1.3.1 | REFUERZO EN ACERO DE 60000 PSI | 14d | 2025-02-24 | 2025-03-11 | 6FF | 58d |  | 747,878 | Día19 | Día32 |
| 11 | 1.1.4 | **DRENAJES** | 14d | 2025-03-29 | 2025-04-14 |  | 0d |  | 14,630,587.65 |  |  |
| 12 | 1.1.4.1 | CONSTRUCCIÓN DE CUNETAS REVESTIDAS EN CONCRETO F'C=3000 PSI (SEGÚN DISEÑO). INCLUYE FORMALETA, CURADO CON ANTISOL Y SELLADO DE JUNTAS. | 14d | 2025-03-29 | 2025-04-14 | 7FS+2d | 0d |  | 14,630,587.65 | Día48 | Día61 |
| 13 | 1.2 | **CONSORCIO VIAL CALI LOTE 2 - FRENTE NUMERO 28 - LA LEONERA - VEREDA EL PORVENIR DESDE LA CASA DE DORA HASTA EL TANQUE DEL ACUEDUCTO FINCA ENTRE AGUAS** | 44d | 2025-03-28 | 2025-05-17 |  | 0d |  | 181,831,008.39 |  |  |
| 14 | 1.2.1 | **MOVIMIENTOS DE TIERRA Y TRANPORTE** | 31d | 2025-03-28 | 2025-05-02 |  | 0d |  | 37,771,310 |  |  |
| 15 | 1.2.1.1 | EXCAVACION EN TIERRA EN SECO A MANO ENTRE 0 - 2 m DE PROFUNDIDAD (INCLUYE MANO DE OBRA Y HERRAMIENTA) | 6d | 2025-04-09 | 2025-04-15 | 12FS-5d | 28d |  | 6,987,710 | Día57 | Día62 |
| 16 | 1.2.1.2 | RETIRO DE MATERIAL DE EXCAVACION CON CARGUE EN VOLQUETA A MANO EN BANCO DE 0 A 10 Km. SIN ACARREO INTERNO EN OBRA. INCLUYE DISPOSICIÓN EN BOTADERO OFICIAL (DECRETO 0291 DE 2005) | 3d | 2025-03-28 | 2025-03-31 | 12FS-15d | 0d |  | 11,978,582 | Día47 | Día49 |
| 17 | 1.2.1.3 | ACARREO DE MATERIAL PETREO SECTOR RURAL. | 20d | 2025-04-10 | 2025-05-02 | 23FF | 13d |  | 18,805,018 | Día58 | Día77 |
| 18 | 1.2.2 | **RELLENOS Y BASES** | 10d | 2025-03-28 | 2025-04-08 |  | 2d |  | 23,465,943.9 |  |  |
| 19 | 1.2.2.1 | ESCARIFICACIÓN, CONFORMACIÓN Y COMPACTACIÓN DE LA SUBRASANTE OBRAS DE MANTENIMIENTO. | 5d | 2025-04-01 | 2025-04-05 | 16 | 0d |  | 5,201,412.3 | Día50 | Día54 |
| 20 | 1.2.2.2 | SUMINISTRO E INSTALACIÓN MATERIAL GRANULAR TIPO INVIAS PARA SUB BASE, COMPACTADA AL 95% DEL P.M. OBRAS DE MANTENIMIENTO. | 10d | 2025-03-28 | 2025-04-08 | 19FF+2d | 34d |  | 16,240,845.6 | Día47 | Día56 |
| 21 | 1.2.2.3 | SUMINISTRO E INSTALACIÓN DE MATERIAL SELECCIONADO TIPO ROCAMUERTA PARA VÍAS. | 8d | 2025-03-31 | 2025-04-08 | 19FF+2d | 0d |  | 2,023,686 | Día49 | Día56 |
| 22 | 1.2.3 | **CONCRETOS** | 34d | 2025-04-09 | 2025-05-17 |  | 0d |  | 60,511,506.6 |  |  |
| 23 | 1.2.3.1 | CONSTRUCCIÓN DE HUELLAS EN CONCRETO SIMPLE MR-38. INCLUYE ANTISOL Y JUNTA. | 21d | 2025-04-09 | 2025-05-02 | 21 | 0d |  | 41,831,142.78 | Día57 | Día77 |
| 24 | 1.2.3.2 | EMPEDRADO PLACA HUELLA- CONCRETO 3000 PSI 60% Y PIEDRA 40%-E=15CMS, INCLUYE CURADO CON ANTISOL. | 13d | 2025-05-03 | 2025-05-17 | 23 | 0d |  | 16,157,961.4 | Día78 | Día90 |
| 25 | 1.2.3.3 | CONSTRUCCIÓN DE VIGUETA DE AMARRE EN CONCRETO DE F'C=3500 PSI DE 15X15 CMS. INCLUYE SUMINISTRO DE CONCRETO SIMPLE, FORMALETA Y CURADO CON ANTISOL. | 6d | 2025-05-12 | 2025-05-17 | 24FF | 0d |  | 2,522,402.42 | Día85 | Día90 |

| ID | WBS | Task | Duration | Start | Finish | Predecessors | Total slack | Cost | INICIO | FINAL |
| --- | --- | --- | --- | --- | --- | --- | --- | --- | --- | --- |
| 26 | 1.2.4 | **ACEROS** | 5d | 2025-05-13 | 2025-05-17 |  | 0d | 22,042,720 |  |  |
| 27 | 1.2.4.1 | REFUERZO EN ACERO DE 60000 PSI | 5d | 2025-05-13 | 2025-05-17 | 25FF | 0d | 22,042,720 | Día86 | Día90 |
| 28 | 1.2.5 | **DRENAJES** | 5d | 2025-05-07 | 2025-05-12 |  | 5d | 38,039,527.89 |  |  |
| 29 | 1.2.5.1 | CONSTRUCCIÓN DE CUNETAS REVESTIDAS EN CONCRETO F'C=3000 PSI (SEGÚN DISEÑO). INCLUYE FORMALETA, CURADO CON ANTISOL Y SELLADO DE JUNTAS. | 5d | 2025-05-07 | 2025-05-12 | 27FS-10d | 5d | 38,039,527.89 | Día81 | Día85 |
| 30 | 1.3 | **CONSORCIO VIAL CALI LOTE 2 -FRENTE NUMERO 29 - LA LEONERA - VEREDA EL PORVENIR VIA AL PATO SECTOR FINCA LA ESPERANZA HACIA LA TERESITA** | 34d | 2025-04-09 | 2025-05-17 |  | 0d | 105,856,525.87 |  |  |
| 31 | 1.3.1 | **MOVIMIENTOS DE TIERRA Y TRANPORTE** | 34d | 2025-04-09 | 2025-05-17 |  | 0d | 19,190,490.4 |  |  |
| 32 | 1.3.1.1 | EXCAVACION EN TIERRA EN SECO A MANO ENTRE 0 - 2 m DE PROFUNDIDAD (INCLUYE MANO DE OBRA Y HERRAMIENTA) | 6d | 2025-04-09 | 2025-04-15 | 12FS-5d | 0d | 3,668,547.75 | Día57 | Día62 |
| 33 | 1.3.1.2 | RETIRO DE MATERIAL DE EXCAVACION CON CARGUE EN VOLQUETA A MAQUINA EN BANCO DE 10 A 20 Km. SIN ACARREO INTERNO EN OBRA. INCLUYE DISPOSICIÓN EN BOTADERO OFICIAL (DECRETO 0291 DE 2005) | 3d | 2025-04-12 | 2025-04-15 | 32FF | 0d | 5,737,003.65 | Día60 | Día62 |
| 34 | 1.3.1.3 | ACARREO DE MATERIAL PETREO SECTOR RURAL. | 27d | 2025-04-17 | 2025-05-17 | 39FF | 0d | 9,784,939 | Día64 | Día90 |
| 35 | 1.3.2 | **RELLENOS Y BASES** | 5d | 2025-04-16 | 2025-04-21 |  | 0d | 11,562,352.2 |  |  |
| 36 | 1.3.2.1 | ESCARIFICACIÓN, CONFORMACIÓN Y COMPACTACIÓN DE LA SUBRASANTE OBRAS DE MANTENIMIENTO. | 5d | 2025-04-16 | 2025-04-21 | 33 | 0d | 3,467,608.2 | Día63 | Día67 |
| 37 | 1.3.2.2 | SUMINISTRO E INSTALACIÓN DE MATERIAL SELECCIONADO TIPO ROCAMUERTA PARA VÍAS. | 5d | 2025-04-16 | 2025-04-21 | 36FF | 0d | 8,094,744 | Día63 | Día67 |
| 38 | 1.3.3 | **DRENAJES** | 27d | 2025-04-17 | 2025-05-17 |  | 0d | 75,103,683.27 |  |  |
| 39 | 1.3.3.1 | CONSTRUCCIÓN DE CUNETAS REVESTIDAS EN CONCRETO F'C=3000 PSI (SEGÚN DISEÑO). INCLUYE FORMALETA, CURADO CON ANTISOL Y SELLADO DE JUNTAS. | 27d | 2025-04-17 | 2025-05-17 | 37FS-4d | 0d | 75,103,683.27 | Día64 | Día90 |
| 40 | 1.4 | **CONSORCIO VIAL CALI LOTE 2 -FRENTE NUMERO 30 - FELIDIA - VERERDA LA ESPERANZA SECTOR LOS PINOS** | 52d | 2025-02-03 | 2025-04-03 |  | 0d | 51,676,420.18 |  |  |
| 41 | 1.4.1 | **MOVIMIENTOS DE TIERRA Y TRANPORTE** | 39d | 2025-02-03 | 2025-03-19 |  | 0d | 7,742,747.42 |  |  |
| 42 | 1.4.1.1 | EXCAVACION EN TIERRA EN SECO A MANO ENTRE 0 - 2 m DE PROFUNDIDAD (INCLUYE MANO DE OBRA Y HERRAMIENTA) | 10d | 2025-02-03 | 2025-02-13 | 4FF | 0d | 2,410,759.95 | Día1 | Día10 |
| 43 | 1.4.1.2 | RETIRO DE MATERIAL DE EXCAVACION CON CARGUE EN VOLQUETA A MAQUINA EN BANCO DE 10 A 20 Km. SIN ACARREO INTERNO EN OBRA. INCLUYE DISPOSICIÓN EN BOTADERO OFICIAL (DECRETO 0291 DE 2005) | 4d | 2025-02-10 | 2025-02-13 | 42FF | 0d | 3,770,030.97 | Día7 | Día10 |
| 44 | 1.4.1.3 | ACARREO DE MATERIAL PETREO SECTOR RURAL. | 20d | 2025-02-25 | 2025-03-19 | 49FF | 51d | 1,561,956.5 | Día20 | Día39 |
| 45 | 1.4.2 | **RELLENOS Y BASES** | 5d | 2025-02-17 | 2025-02-21 |  | 0d | 8,196,698.4 |  |  |
| 46 | 1.4.2.1 | ESCARIFICACIÓN, CONFORMACIÓN Y COMPACTACIÓN DE LA SUBRASANTE OBRAS DE MANTENIMIENTO. | 5d | 2025-02-17 | 2025-02-21 | 43FS+2d | 0d | 1,816,366.2 | Día13 | Día17 |
| 47 | 1.4.2.2 | SUMINISTRO E INSTALACIÓN MATERIAL GRANULAR TIPO INVIAS PARA SUB BASE, COMPACTADA AL 95% DEL P.M. OBRAS DE MANTENIMIENTO. | 1d | 2025-02-21 | 2025-02-21 | 46FF | 0d | 6,380,332.2 | Día17 | Día17 |
| 48 | 1.4.3 | **ACARREO DE MATERIAL PETREO SECTOR RURAL** | 33d | 2025-02-25 | 2025-04-03 |  | 0d | 30,060,973.96 |  |  |
| 49 | 1.4.3.1 | CONSTRUCCIÓN DE HUELLAS EN CONCRETO SIMPLE MR-40. INCLUYE ANTISOL Y JUNTA. | 20d | 2025-02-25 | 2025-03-19 | 47FS+2d | 0d | 26,124,479.77 | Día20 | Día39 |
| 50 | 1.4.3.2 | EMPEDRADO PLACA HUELLA- CONCRETO 3000 PSI 60% Y PIEDRA 40%-E=15CMS, INCLUYE CURADO CON ANTISOL. | 12d | 2025-03-21 | 2025-04-03 | 49FS+1d | 0d | 3,000,764.26 | Día41 | Día52 |
| 51 | 1.4.3.3 | CONSTRUCCIÓN DE VIGUETA DE AMARRE EN CONCRETO DE F'C=3500 PSI DE 15X15 CMS. INCLUYE SUMINISTRO DE CONCRETO SIMPLE, FORMALETA Y CURADO CON ANTISOL. | 6d | 2025-03-28 | 2025-04-03 | 50FF | 0d | 935,729.93 | Día47 | Día52 |

| ID | WBS | Task | Duration | Start | Finish | Predecessors | Total slack | Cost | INICIO | FINAL |
| --- | --- | --- | --- | --- | --- | --- | --- | --- | --- | --- |
| 52 | 1.4.4 | **ACEROS** | 3d | 2025-04-01 | 2025-04-03 |  | 38d | 5,676,000.4 |  |  |
| 53 | 1.4.4.1 | REFUERZO EN ACERO DE 60000 PSI | 3d | 2025-04-01 | 2025-04-03 | 51FF | 38d | 5,676,000.4 | Día50 | Día52 |
| 54 | 1.5 | **CONSORCIO VIAL CALI LOTE 2 -FRENTE NUMERO 32 - FELIDIA - VEREDA EL DIAMANTE SECTOR LA SOLEDAD CASA EL RINCON DE LA ABUELA** | 40d | 2025-02-03 | 2025-03-20 |  | 0d | 12,937,629.55 |  |  |
| 55 | 1.5.1 | **MOVIMIENTOS DE TIERRA Y TRANPORTE** | 17d | 2025-02-03 | 2025-02-21 |  | 0d | 2,020,988.56 |  |  |
| 56 | 1.5.1.1 | EXCAVACION EN TIERRA EN SECO A MANO ENTRE 0 - 2 m DE PROFUNDIDAD (INCLUYE MANO DE OBRA Y HERRAMIENTA) | 7d | 2025-02-03 | 2025-02-10 |  | 0d | 593,955.35 | Día1 | Día7 |
| 57 | 1.5.1.2 | RETIRO DE MATERIAL DE EXCAVACION CON CARGUE EN VOLQUETA A MAQUINA EN BANCO DE 10 A 20 Km. SIN ACARREO INTERNO EN OBRA. INCLUYE DISPOSICIÓN EN BOTADERO OFICIAL (DECRETO 0291 DE 2005) | 4d | 2025-02-13 | 2025-02-17 | 56FS+2d | 0d | 928,848.21 | Día10 | Día13 |
| 58 | 1.5.1.3 | ACARREO DE MATERIAL PETREO SECTOR RURAL. | 2d | 2025-02-20 | 2025-02-21 | 57FS+2d | 73d | 498,185 | Día16 | Día17 |
| 59 | 1.5.2 | **RELLENOS Y BASES** | 26d | 2025-02-19 | 2025-03-20 |  | 0d | 1,319,558.8 |  |  |
| 60 | 1.5.2.1 | ESCARIFICACIÓN, CONFORMACIÓN Y COMPACTACIÓN DE LA SUBRASANTE OBRAS DE MANTENIMIENTO. | 2d | 2025-03-19 | 2025-03-20 | 65 | 0d | 660,496.8 | Día39 | Día40 |
| 61 | 1.5.2.2 | SUMINISTRO E INSTALACIÓN DE MATERIAL SELECCIONADO TIPO ROCAMUERTA PARA ESTRUCTURAS. | 4d | 2025-02-19 | 2025-02-22 | 57FS+1d | 0d | 659,062 | Día15 | Día18 |
| 62 | 1.5.3 | **ACEROS** | 2d | 2025-02-26 | 2025-02-27 |  | 0d | 818,729.6 |  |  |
| 63 | 1.5.3.1 | REFUERZO EN ACERO DE 60000 PSI. | 2d | 2025-02-26 | 2025-02-27 | 61SF+8d | 0d | 818,729.6 | Día21 | Día22 |
| 64 | 1.5.4 | **DRENAJES** | 15d | 2025-03-01 | 2025-03-18 |  | 0d | 8,778,352.59 |  |  |
| 65 | 1.5.4.1 | CONSTRUCCIÓN DE CUNETAS REVESTIDAS EN CONCRETO F'C=3000 PSI (SEGÚN DISEÑO). INCLUYE FORMALETA, CURADO CON ANTISOL Y SELLADO DE JUNTAS. | 15d | 2025-03-01 | 2025-03-18 | 63FS+1d | 0d | 8,778,352.59 | Día24 | Día38 |
| 66 | 1.6 | **CONSORCIO VIAL CALI LOTE 2 -FRENTE NUMERO 33 - FELIDIA - VEREDA EL DIAMANTE SECTOR EL CEDRAL INICIO EN CRUCERO Y FINALIZA EN FINCA DE BERNARDO CAICEDO** | 50d | 2025-03-21 | 2025-05-17 |  | 0d | 61,058,364.41 |  |  |
| 67 | 1.6.1 | **MOVIMIENTOS DE TIERRA Y TRANSPORTE** | 11d | 2025-03-21 | 2025-04-02 |  | 0d | 2,478,932.28 |  |  |
| 68 | 1.6.1.1 | EXCAVACION EN TIERRA EN SECO A MANO ENTRE 0 - 2 m DE PROFUNDIDAD (INCLUYE MANO DE OBRA Y HERRAMIENTA) | 6d | 2025-03-21 | 2025-03-27 | 60 | 0d | 733,709.55 | Día41 | Día46 |
| 69 | 1.6.1.2 | RETIRO DE MATERIAL DE EXCAVACION CON CARGUE EN VOLQUETA A MAQUINA EN BANCO DE 10 A 20 Km. SIN ACARREO INTERNO EN OBRA. INCLUYE DISPOSICIÓN EN BOTADERO OFICIAL (DECRETO 0291 DE 2005) | 4d | 2025-03-24 | 2025-03-27 | 68FF | 44d | 1,147,400.73 | Día43 | Día46 |
| 70 | 1.6.1.3 | ACARREO DE MATERIAL PETREO SECTOR RURAL. | 10d | 2025-03-22 | 2025-04-02 | 68SS+1d | 0d | 597,822 | Día42 | Día51 |
| 71 | 1.6.2 | **RELLENOS Y BASES** | 4d | 2025-03-25 | 2025-03-28 |  | 0d | 1,954,405.2 |  |  |
| 72 | 1.6.2.1 | ESCARIFICACIÓN, CONFORMACIÓN Y COMPACTACIÓN DE LA SUBRASANTE OBRAS DE MANTENIMIENTO. | 4d | 2025-03-25 | 2025-03-28 | 70SS+2d | 43d | 990,745.2 | Día44 | Día47 |
| 73 | 1.6.2.2 | SUMINISTRO E INSTALACIÓN DE MATERIAL SELECCIONADO TIPO ROCAMUERTA PARA VÍAS. | 4d | 2025-03-25 | 2025-03-28 | 70SS+2d | 0d | 963,660 | Día44 | Día47 |
| 74 | 1.6.3 | **ACEROS** | 8d | 2025-03-21 | 2025-03-29 |  | 0d | 984,050 |  |  |
| 75 | 1.6.3.1 | REFUERZO EN ACERO DE 60000 PSI | 8d | 2025-03-21 | 2025-03-29 | 73FF+1d | 0d | 984,050 | Día41 | Día48 |

| ID | WBS | Task | Duration | Start | Finish | Predecessors | Total slack | Free slack | Cost | INICIO | FINAL |
| --- | --- | --- | --- | --- | --- | --- | --- | --- | --- | --- | --- |
| 76 | 1.6.4 | **DRENAJES** | 41d | 2025-04-01 | 2025-05-17 |  | 0d |  | 55,640,976.93 |  |  |
| 77 | 1.6.4.1 | CONSTRUCCIÓN DE CABEZAL EN CONCRETO F'C=3000 PSI (SEGÚN DISEÑO). INCLUYE FORMALETA Y CURADO CON ANTISOL. | 21d | 2025-04-01 | 2025-04-24 | 75FS+1d | 0d |  | 44,911,879.32 | Día50 | Día70 |
| 78 | 1.6.4.2 | CONSTRUCCIÓN DE CUNETAS REVESTIDAS EN CONCRETO F'C=3000 PSI (SEGÚN DISEÑO). INCLUYE FORMALETA, CURADO CON ANTISOL Y SELLADO DE JUNTAS. | 20d | 2025-04-25 | 2025-05-17 | 77 | 0d |  | 10,729,097.61 | Día71 | Día90 |
| 79 | 1.7 | **CONSORCIO VIAL CALI LOTE 2 -FRENTE NUMERO 34 - FELIDIA - VEREDA SANTA ELENA BAJA SECTOR HIGUERONES** | 34d | 2025-03-21 | 2025-04-29 |  | 16d |  | 13,026,445.55 |  |  |
| 80 | 1.7.1 | **MOVIMIENTOS DE TIERRA Y TRANPORTE** | 31d | 2025-03-21 | 2025-04-25 |  | 16d |  | 2,020,988.56 |  |  |
| 81 | 1.7.1.1 | EXCAVACION EN TIERRA EN SECO A MANO ENTRE 0 - 2 m DE PROFUNDIDAD (INCLUYE MANO DE OBRA Y HERRAMIENTA) | 7d | 2025-03-21 | 2025-03-28 | 65FS+2d | 16d | 0d | 593,955.35 | Día41 | Día47 |
| 82 | 1.7.1.2 | RETIRO DE MATERIAL DE EXCAVACION CON CARGUE EN VOLQUETA A MAQUINA EN BANCO DE 10 A 20 Km. SIN ACARREO INTERNO EN OBRA. INCLUYE DISPOSICIÓN EN BOTADERO OFICIAL (DECRETO 0291 DE 2005) | 5d | 2025-03-24 | 2025-03-28 | 81FF | 16d | 0d | 928,848.21 | Día43 | Día47 |
| 83 | 1.7.1.3 | ACARREO DE MATERIAL PETREO SECTOR RURAL. | 5d | 2025-04-21 | 2025-04-25 | 90FF | 19d |  | 498,185 | Día67 | Día71 |
| 84 | 1.7.2 | **RELLENOS Y BASES** | 25d | 2025-04-01 | 2025-04-29 |  | 16d |  | 1,408,374.8 |  |  |
| 85 | 1.7.2.1 | ESCARIFICACIÓN, CONFORMACIÓN Y COMPACTACIÓN DE LA SUBRASANTE OBRAS DE MANTENIMIENTO. | 2d | 2025-04-28 | 2025-04-29 | 90FS+1d | 16d |  | 660,496.8 | Día73 | Día74 |
| 86 | 1.7.2.2 | SUMINISTRO E INSTALACIÓN DE MATERIAL SELECCIONADO TIPO ROCAMUERTA PARA ESTRUCTURAS. | 4d | 2025-04-01 | 2025-04-04 | 82FS+2d | 16d | 0d | 747,878 | Día50 | Día53 |
| 87 | 1.7.3 | **ACEROS** | 2d | 2025-04-03 | 2025-04-04 |  | 16d |  | 818,729.6 |  |  |
| 88 | 1.7.3.1 | REFUERZO EN ACERO DE 60000 PSI. | 2d | 2025-04-03 | 2025-04-04 | 86FS-2d | 16d | 0d | 818,729.6 | Día52 | Día53 |
| 89 | 1.7.4 | **DRENAJES** | 15d | 2025-04-09 | 2025-04-25 |  | 16d |  | 8,778,352.59 |  |  |
| 90 | 1.7.4.1 | CONSTRUCCIÓN DE CUNETAS REVESTIDAS EN CONCRETO F'C=3000 PSI (SEGÚN DISEÑO). INCLUYE FORMALETA, CURADO CON ANTISOL Y SELLADO DE JUNTAS. | 15d | 2025-04-09 | 2025-04-25 | 88FS+3d | 16d | 0d | 8,778,352.59 | Día57 | Día71 |
| 91 | 1.8 | **CONSORCIO VIAL CALI LOTE 2 -FRENTE NUMERO 35 - FELIDIA - VEREDA LA ESPERANZA SECTOR LOS PINOS** | 90d | 2025-02-03 | 2025-05-17 |  | 0d |  | 43,500,683.6 |  |  |
| 92 | 1.8.1 | **MOVIMIENTOS DE TIERRA Y TRANPORTE** | 90d | 2025-02-03 | 2025-05-17 |  | 0d |  | 6,749,881.26 |  |  |
| 93 | 1.8.1.1 | EXCAVACION EN TIERRA EN SECO A MANO ENTRE 0 - 2 m DE PROFUNDIDAD (INCLUYE MANO DE OBRA Y HERRAMIENTA) | 10d | 2025-02-03 | 2025-02-13 | 42FF | 80d | 0d | 1,991,497.35 | Día1 | Día10 |
| 94 | 1.8.1.2 | RETIRO DE MATERIAL DE EXCAVACION CON CARGUE EN VOLQUETA A MAQUINA EN BANCO DE 10 A 20 Km. SIN ACARREO INTERNO EN OBRA. INCLUYE DISPOSICIÓN EN BOTADERO OFICIAL (DECRETO 0291 DE 2005) | 4d | 2025-02-10 | 2025-02-13 | 93FF | 80d |  | 3,114,373.41 | Día7 | Día10 |
| 95 | 1.8.1.3 | ACARREO DE MATERIAL PETREO SECTOR RURAL. | 5d | 2025-05-13 | 2025-05-17 | 102FF | 0d |  | 1,644,010.5 | Día86 | Día90 |
| 96 | 1.8.2 | **RELLENOS Y BASES** | 48d | 2025-02-14 | 2025-04-10 |  | 32d |  | 4,781,521.44 |  |  |
| 97 | 1.8.2.1 | ESCARIFICACIÓN, CONFORMACIÓN Y COMPACTACIÓN DE LA SUBRASANTE OBRAS DE MANTENIMIENTO. | 7d | 2025-02-14 | 2025-02-21 | 47FF | 73d |  | 2,179,639.44 | Día11 | Día17 |
| 98 | 1.8.2.2 | SUMINISTRO E INSTALACIÓN DE MATERIAL SELECCIONADO TIPO ROCAMUERTA PARA VÍAS. | 5d | 2025-04-05 | 2025-04-10 | 51FS+1d | 0d |  | 2,601,882 | Día54 | Día58 |
| 99 | 1.8.3 | **ACERO** | 6d | 2025-04-17 | 2025-04-23 |  | 0d |  | 2,708,105.6 |  |  |
| 100 | 1.8.3.1 | REFUERZO EN ACERO DE 60000 PSI. | 6d | 2025-04-17 | 2025-04-23 | 98FS+5d | 0d |  | 2,708,105.6 | Día64 | Día69 |

| ID | WBS | Task | Duration | Start | Finish | Predecessors | Total slack | Free slack | Cost | INICIO | FINAL |
| --- | --- | --- | --- | --- | --- | --- | --- | --- | --- | --- | --- |
| 101 | 1.8.4 | **DRENAJES** | 16d | 2025-04-30 | 2025-05-17 |  | 0d |  | 29,261,175.3 |  |  |
| 102 | 1.8.4.1 | CONSTRUCCIÓN DE CUNETAS REVESTIDAS EN CONCRETO F'C=3000 PSI (SEGÚN DISEÑO). INCLUYE FORMALETA, CURADO CON ANTISOL Y SELLADO DE JUNTAS. | 16d | 2025-04-30 | 2025-05-17 | 100FS+5d | 0d |  | 29,261,175.3 | Día75 | Día90 |
| 103 | 1.9 | **CONSORCIO VIAL CALI LOTE 2 -FRENTE NUMERO 36 - PICHINDE - VIA LA CAJITA SECTOR SEDE COMUNAL** | 45d | 2025-03-27 | 2025-05-17 |  | 0d |  | 18,404,176.9 |  |  |
| 104 | 1.9.1 | **CONCRETOS** | 25d | 2025-03-27 | 2025-04-24 |  | 0d |  | 16,081,818.9 |  |  |
| 105 | 1.9.1.1 | CONSTRUCCIÓN DE HUELLAS EN CONCRETO SIMPLE MR-40. INCLUYE ANTISOL Y JUNTA. | 15d | 2025-03-27 | 2025-04-12 | 125FS+2d | 0d |  | 13,008,039.72 | Día46 | Día60 |
| 106 | 1.9.1.2 | EMPEDRADO PLACA HUELLA- CONCRETO 3000 PSI 60% Y PIEDRA 40%-E=15CMS, INCLUYE CURADO CON ANTISOL. | 7d | 2025-04-17 | 2025-04-24 | 105FS+3d | 0d |  | 1,731,210.15 | Día64 | Día70 |
| 107 | 1.9.1.3 | CONSTRUCCIÓN DE VIGUETA DE AMARRE EN CONCRETO DE F'C=3500 PSI DE 15X15 CMS. INCLUYE SUMINISTRO DE CONCRETO SIMPLE, FORMALETA Y CURADO CON ANTISOL. | 7d | 2025-04-17 | 2025-04-24 | 106FF | 0d |  | 1,342,569.03 | Día64 | Día70 |
| 108 | 1.9.2 | **ACEROS** | 6d | 2025-04-19 | 2025-04-25 |  | 19d |  | 1,574,480 |  |  |
| 109 | 1.9.2.1 | REFUERZO EN ACERO DE 60000 PSI. | 6d | 2025-04-19 | 2025-04-25 | 107FF+1d | 19d |  | 1,574,480 | Día66 | Día71 |
| 110 | 1.9.3 | **DRENAJES** | 30d | 2025-04-14 | 2025-05-17 |  | 0d |  | 747,878 |  |  |
| 111 | 1.9.3.1 | CONSTRUCCIÓN DE CUNETAS REVESTIDAS EN CONCRETO F'C=3000 PSI (SEGÚN DISEÑO). INCLUYE FORMALETA, CURADO CON ANTISOL Y SELLADO DE JUNTAS. | 30d | 2025-04-14 | 2025-05-17 | 107FS-10d | 0d |  | 747,878 | Día61 | Día90 |
| 112 | 1.10 | **CONSORCIO VIAL CALI LOTE 2 -FRENTE NUMERO 37 - PICHINDE - CORREGIMIENTO PICHINDE VIA CEMENTERIO** | 63d | 2025-02-03 | 2025-04-16 |  | 0d |  | 71,034,870.64 |  |  |
| 113 | 1.10.1 | **DEMOLICIONES** | 3d | 2025-02-03 | 2025-02-05 |  | 0d |  | 183,483.3 |  |  |
| 114 | 1.10.1.1 | DEMOLICION DE ANDEN EN CONCRETO SIMPLE A MAQUINA HASTA 10 CMS DE ESPESOR INCLUYE CARGUE, TRANSPORTE Y RETIRO DE ESCOMBROS. | 3d | 2025-02-03 | 2025-02-05 | 4SS | 0d |  | 183,483.3 | Día1 | Día3 |
| 115 | 1.10.2 | **MOVIMIENTOS DE TIERRA Y TRANPORTE** | 39d | 2025-02-07 | 2025-03-24 |  | 0d |  | 4,864,160 |  |  |
| 116 | 1.10.2.1 | EXCAVACION EN TIERRA EN SECO A MANO ENTRE 0 - 2 m DE PROFUNDIDAD (INCLUYE MANO DE OBRA Y HERRAMIENTA) | 10d | 2025-02-07 | 2025-02-18 | 114FS+1d | 0d |  | 1,788,853 | Día5 | Día14 |
| 117 | 1.10.2.2 | RETIRO DE MATERIAL DE EXCAVACION CON CARGUE EN VOLQUETA A MANO EN BANCO DE 0 A 10 Km. SIN ACARREO INTERNO EN OBRA. INCLUYE DISPOSICIÓN EN BOTADERO OFICIAL (DECRETO 0291 DE 2005) | 4d | 2025-02-14 | 2025-02-18 | 116FF | 76d |  | 3,066,516 | Día11 | Día14 |
| 118 | 1.10.2.3 | ACARREO DE MATERIAL PETREO SECTOR RURAL. | 4d | 2025-03-20 | 2025-03-24 | 125FF | 47d |  | 8,791 | Día40 | Día43 |
| 119 | 1.10.3 | **RELLENOS Y BASES** | 21d | 2025-02-21 | 2025-03-17 |  | 0d |  | 13,744,945 |  |  |
| 120 | 1.10.3.1 | ESCARIFICACIÓN, CONFORMACIÓN Y COMPACTACIÓN DE LA SUBRASANTE OBRAS DE MANTENIMIENTO. | 15d | 2025-02-21 | 2025-03-10 | 116FS+2d | 0d |  | 412,810 | Día17 | Día31 |
| 121 | 1.10.3.2 | SUMINISTRO E INSTALACIÓN MATERIAL GRANULAR TIPO INVIAS PARA SUB BASE, COMPACTADA AL 95% DEL P.M. OBRAS DE MANTENIMIENTO. | 5d | 2025-03-12 | 2025-03-17 | 120FS+1d | 0d |  | 10,633,887 | Día33 | Día37 |
| 122 | 1.10.3.3 | SUMINISTRO E INSTALACIÓN DE MATERIAL SELECCIONADO TIPO ROCAMUERTA PARA VÍAS. | 3d | 2025-03-08 | 2025-03-11 | 120FF+1d | 51d | 0d | 2,698,248 | Día30 | Día32 |
| 123 | 1.10.4 | **CONCRETOS** | 5d | 2025-03-19 | 2025-03-24 |  | 0d |  | 18,213,653 |  |  |
| 124 | 1.10.4.1 | CONSTRUCCIÓN DE HUELLAS EN CONCRETO SIMPLE MR-40 ACELERADO A 7 DÍAS. INCLUYE ANTISOL Y JUNTA. | 2d | 2025-03-20 | 2025-03-21 | 121FS+2d | 49d | 0d | 2,233,419 | Día40 | Día41 |
| 125 | 1.10.4.2 | EMPEDRADO PLACA HUELLA- CONCRETO 3000 PSI 60% Y PIEDRA 40%-E=15CMS, INCLUYE CURADO CON ANTISOL. | 5d | 2025-03-19 | 2025-03-24 | 121FS+1d | 0d |  | 15,003,821 | Día39 | Día43 |
| 126 | 1.10.4.3 | CONSTRUCCIÓN DE VIGUETA DE AMARRE EN CONCRETO DE F'C=3500 PSI DE 15X15 CMS. INCLUYE SUMINISTRO DE CONCRETO SIMPLE, FORMALETA Y CURADO CON ANTISOL. | 2d | 2025-03-20 | 2025-03-21 | 124FF | 49d |  | 976,413 | Día40 | Día41 |

| ID | WBS | Task | Duration | Start | Finish | Predecessors | Total slack | Cost | INICIO | FINAL |
| --- | --- | --- | --- | --- | --- | --- | --- | --- | --- | --- |
| 127 | 1.10.5 | **ACEROS** | 5d | 2025-03-14 | 2025-03-19 |  | 51d | 865,964 |  |  |
| 128 | 1.10.5.1 | REFUERZO EN ACERO DE 60000 PSI. | 5d | 2025-03-14 | 2025-03-19 | 122FS+2d | 51d | 865,964 | Día35 | Día39 |
| 129 | 1.10.6 | **DRENAJES** | 20d | 2025-03-25 | 2025-04-16 |  | 27d | 33,162,665.34 |  |  |
| 130 | 1.10.6.1 | CONSTRUCCIÓN DE CUNETAS REVESTIDAS EN CONCRETO F'C=3000 PSI (SEGÚN DISEÑO). INCLUYE FORMALETA, CURADO CON ANTISOL Y SELLADO DE JUNTAS. | 20d | 2025-03-25 | 2025-04-16 | 125 | 27d | 33,162,665.34 | Día44 | Día63 |
